# NCBO Core 2

Schedule from MS Project MPX, 2005-10-03 to 2007-07-06.
University of California Berkeley

## Calendars

- Standard: Mon-Fri 08:00-12:00, 13:00-17:00; Sat-Sun off. Exceptions (off unless hours are given): 2005-11-19 08:00-12:00, 13:00-17:00, 2005-12-11 08:00-12:00, 13:00-17:00, 2006-01-08 08:00-12:00, 13:00-17:00, 2006-01-29 08:00-12:00, 13:00-17:00, 2006-05-14 08:00-12:00, 13:00-17:00.

## Resources

| Resource |
| --- |
| Monte |
| Michael |
| Chris Mungall |
| ShengQiang Shu |
| Mark Gibson |
| Nomi Harris |
| Suzanna Lewis |
| Sima Misra |
| John Day-Richter |

## Schedule

| ID | WBS | Task | Duration | Start | Finish | Total slack | Constraint | Resources |
| --- | --- | --- | --- | --- | --- | --- | --- | --- |
| 1 | 1 | **Administrative** | 465d | 2005-10-03 | 2007-07-06 | 0d |  |  |
| 2 | 1.1 | **cBiO Berkeley staff** | 195.13d | 2005-10-17 | 2006-07-10 | 259.88d |  |  |
| 3 | 1.1.1 | cBiO Core 1/2 meeting | 1.72h | 2005-10-17 | 2005-10-17 | 3638.28h | start no earlier than 2005-10-17 | Chris Mungall; Mark Gibson; Nomi Harris; ShengQiang Shu; Sima Misra; Suzanna Lewis; John Day-Richter |
| 4 | 1.1.2 | cBiO Core 1/2 meeting | 1.72h | 2005-11-07 | 2005-11-07 | 3518.28h | start no earlier than 2005-11-07 | Chris Mungall; Mark Gibson; Nomi Harris; ShengQiang Shu; Sima Misra; Suzanna Lewis; John Day-Richter |
| 5 | 1.1.3 | Phenotype Ontology workshop, CSHL | 1.2d | 2005-11-19 | 2005-11-21 | 428.8d | start no earlier than 2005-11-19 | Chris Mungall; John Day-Richter; Suzanna Lewis; Michael; Monte |
| 6 | 1.1.4 | cBiO Core 1/2 meeting | 4.28h | 2005-11-21 | 2005-11-21 | 3427.72h | start no earlier than 2005-11-21 | Chris Mungall; Mark Gibson; Nomi Harris; ShengQiang Shu; Sima Misra; Suzanna Lewis; John Day-Richter |
| 7 | 1.1.5 | cBiO Core 1/2 meeting | 4.28h | 2005-11-22 | 2005-11-22 | 3419.72h | start no earlier than 2005-11-22 | Chris Mungall; Mark Gibson; Nomi Harris; ShengQiang Shu; Sima Misra; Suzanna Lewis; John Day-Richter |
| 8 | 1.1.6 | Phenote meeting: ZFIN, FB, UVic, Berkeley | 3d | 2005-12-11 | 2005-12-13 | 411d | start no earlier than 2005-12-11 | Chris Mungall; Mark Gibson; Monte; Suzanna Lewis |
| 9 | 1.1.7 | cBiO Core 1/2 meeting | 1h | 2005-12-13 | 2005-12-13 | 3295h | start no earlier than 2005-12-13 | Chris Mungall; Mark Gibson; Nomi Harris; ShengQiang Shu; Sima Misra; Suzanna Lewis |
| 10 | 1.1.8 | cBiO Core 1/2 meeting | 1h | 2006-01-09 | 2006-01-09 | 3135h | start no earlier than 2006-01-09 | Chris Mungall; Mark Gibson; Nomi Harris; ShengQiang Shu; Sima Misra; Suzanna Lewis |
| 11 | 1.1.9 | Meeting with Lead Science Officer | 1d | 2006-01-11 | 2006-01-11 | 389d | start no earlier than 2006-01-11 | Chris Mungall; John Day-Richter; Nomi Harris; ShengQiang Shu; Sima Misra; Suzanna Lewis |
| 12 | 1.1.10 | cBio PharmGKB meeting | 2h | 2006-01-31 | 2006-01-31 | 2998h | start no earlier than 2006-01-31 | Sima Misra; Suzanna Lewis |
| 13 | 1.1.11 | UCSF/Berkeley/Stanford meeting | 2h | 2006-02-17 | 2006-02-17 | 2894h | start no earlier than 2006-02-17 | Chris Mungall; Mark Gibson; ShengQiang Shu; Suzanna Lewis; Sima Misra |
| 14 | 1.1.12 | Phenote meeting: ZFIN, Berkeley | 3d | 2006-02-21 | 2006-02-23 | 357d | start no earlier than 2006-02-21 | Chris Mungall; John Day-Richter; Mark Gibson; ShengQiang Shu; Suzanna Lewis |
| 15 | 1.1.13 | cBiO Project meeting | 2.5d | 2006-03-02 | 2006-03-06 | 350.5d | start no earlier than 2006-03-02 | Chris Mungall; John Day-Richter; Mark Gibson; Nomi Harris; ShengQiang Shu; Sima Misra; Suzanna Lewis |
| 16 | 1.1.14 | cBiO Core 1/2 meeting | 1h | 2006-03-13 | 2006-03-13 | 2767h | start no earlier than 2006-03-13 | Chris Mungall; John Day-Richter; Mark Gibson; Nomi Harris; ShengQiang Shu; Sima Misra; Suzanna Lewis |
| 17 | 1.1.15 | cBiO Core 1/2 meeting | 1h | 2006-03-28 | 2006-03-28 | 2679h | start no earlier than 2006-03-28 | Chris Mungall; John Day-Richter; Mark Gibson; Nomi Harris; ShengQiang Shu; Sima Misra; Suzanna Lewis |
| 18 | 1.1.16 | cBiO Core 1/2 meeting | 1h | 2006-04-10 | 2006-04-10 | 2607h | start no earlier than 2006-04-10 | Chris Mungall; John Day-Richter; Mark Gibson; Nomi Harris; ShengQiang Shu; Sima Misra; Suzanna Lewis |
| 19 | 1.1.17 | cBiO Core 1/2 meeting | 1h | 2006-04-24 | 2006-04-24 | 2527h | start no earlier than 2006-04-24 | Chris Mungall; John Day-Richter; Mark Gibson; Nomi Harris; ShengQiang Shu; Sima Misra; Suzanna Lewis |
| 20 | 1.1.18 | cBiO Core 1/2 meeting | 1h | 2006-05-08 | 2006-05-08 | 2447h | start no earlier than 2006-05-08 | Chris Mungall; John Day-Richter; Mark Gibson; Nomi Harris; ShengQiang Shu; Sima Misra; Suzanna Lewis |
| 21 | 1.1.19 | Phenotype Ontology workshop, Cambridge | 2d | 2006-05-19 | 2006-05-22 | 294d | start no earlier than 2006-05-19 | Chris Mungall; Mark Gibson; Suzanna Lewis |
| 22 | 1.1.20 | cBiO Core 1/2 meeting | 1h | 2006-05-22 | 2006-05-22 | 2359h | start no earlier than 2006-05-22 | Chris Mungall; John Day-Richter; Mark Gibson; Nomi Harris; ShengQiang Shu; Sima Misra; Suzanna Lewis |
| 23 | 1.1.21 | cBiO Core 1/2 meeting | 1h | 2006-06-05 | 2006-06-05 | 2279h | start no earlier than 2006-06-05 | Chris Mungall; John Day-Richter; Mark Gibson; Nomi Harris; ShengQiang Shu; Sima Misra; Suzanna Lewis |
| 24 | 1.1.22 | cBiO Core 1/2 meeting | 1h | 2006-06-19 | 2006-06-19 | 2199h | start no earlier than 2006-06-19 | Chris Mungall; John Day-Richter; Mark Gibson; Nomi Harris; ShengQiang Shu; Sima Misra; Suzanna Lewis |
| 25 | 1.1.23 | cBiO Core 1/2 meeting | 1h | 2006-07-10 | 2006-07-10 | 2079h | start no earlier than 2006-07-10 | Chris Mungall; John Day-Richter; Mark Gibson; Nomi Harris; ShengQiang Shu; Sima Misra; Suzanna Lewis |

| ID | WBS | Task | Type | Duration | Start | Finish | Predecessors | Total slack | Constraint | Resources |
| --- | --- | --- | --- | --- | --- | --- | --- | --- | --- | --- |
| 26 | 1.2 | **Ontology issues** |  | 139d | 2006-01-03 | 2006-07-11 |  | 77d |  |  |
| 27 | 1.2.1 | Resolve known problems in PATO |  | 3mon | 2006-01-03 | 2006-03-23 |  | 3.85mon | start no earlier than 2006-01-03 | Chris Mungall |
| 28 | 1.2.2 | Alignment of anatomy ontologies (fish & fly) |  | 2mon | 2006-05-17 | 2006-07-11 |  | 12.9mon | start no earlier than 2006-05-17 | Chris Mungall |
| 29 | 1.3 | **Phenote** |  | 465d | 2005-10-03 | 2007-07-06 |  | 0d |  |  |
| 30 | 1.3.1 | Specification of Pheno-XML |  | 2mon | 2006-01-03 | 2006-02-23 |  | 17.85mon | start no earlier than 2006-01-03 | Chris Mungall[20%] |
| 31 | 1.3.2 | Specification of Pheno-XML |  | 2mon | 2006-05-22 | 2006-07-14 |  | 12.75mon | start no earlier than 2006-05-22 | Chris Mungall[20%] |
| 32 | 1.3.3 | **User requirements** |  | 120d | 2005-12-11 | 2006-05-22 |  | 294d |  |  |
| 33 | 1.3.3.1 | Phenote meeting: ZFIN, FB, UVic, Berkeley |  | 3d | 2005-12-11 | 2005-12-13 |  | 411d | start no earlier than 2005-12-11 | Chris Mungall; Mark Gibson; Monte; Suzanna Lewis |
| 34 | 1.3.3.2 | ZFIN user requirement gathering at UOregon |  | 8d | 2006-01-08 | 2006-01-17 |  | 385d | start no earlier than 2006-01-08 | Mark Gibson |
| 35 | 1.3.3.3 | FlyBase user requirement gathering at Cambridge |  | 6d | 2006-01-29 | 2006-02-03 |  | 371d | start no earlier than 2006-01-29 | Mark Gibson |
| 36 | 1.3.3.4 | Phenote meeting: ZFIN, Berkeley |  | 3d | 2006-02-21 | 2006-02-23 |  | 357d | start no earlier than 2006-02-21 | Chris Mungall; John Day-Richter; Mark Gibson; ShengQiang Shu; Suzanna Lewis |
| 37 | 1.3.3.5 | FlyBase user requirement gathering at Cambridge |  | 7d | 2006-05-14 | 2006-05-22 |  | 294d | start no earlier than 2006-05-14 | Mark Gibson |
| 38 | 1.3.4 | Design |  | 9d | 2005-12-12 | 2005-12-22 |  | 404d | start no earlier than 2005-12-12 | Mark Gibson |
| 39 | 1.3.5 | Development |  | 15d | 2006-01-09 | 2006-01-27 |  | 377d | start no earlier than 2006-01-09 | Mark Gibson |
| 40 | 1.3.6 | Development |  | 11d | 2006-02-06 | 2006-02-20 |  | 360d | start no earlier than 2006-02-06 | Mark Gibson |
| 41 | 1.3.7 | Development |  | 4d | 2006-02-24 | 2006-03-01 |  | 353d | start no earlier than 2006-02-24 | Mark Gibson |
| 42 | 1.3.8 | Deployment r0.1 | milestone | 1d | 2006-03-01 | 2006-03-01 |  | 353d | start no earlier than 2006-03-01 | Mark Gibson |
| 43 | 1.3.9 | Design |  | 5d | 2006-03-06 | 2006-03-10 |  | 346d | start no earlier than 2006-03-06 | Mark Gibson |
| 44 | 1.3.10 | Development |  | 10d | 2006-03-13 | 2006-03-24 |  | 336d | start no earlier than 2006-03-13 | Mark Gibson |
| 45 | 1.3.11 | Deployment r0.2 | milestone | 1d | 2006-03-27 | 2006-03-27 |  | 335d | start no earlier than 2006-03-27 | Mark Gibson |
| 46 | 1.3.12 | Development |  | 8d | 2006-03-28 | 2006-04-06 |  | 327d | start no earlier than 2006-03-28 | Mark Gibson |
| 47 | 1.3.13 | Deployment r0.3 | milestone | 1d | 2006-04-07 | 2006-04-07 |  | 326d | start no earlier than 2006-04-07 | Mark Gibson |
| 48 | 1.3.14 | Deployment r0.3.1 (NESCent) | milestone | 1d | 2006-04-07 | 2006-04-07 |  | 326d | start no earlier than 2006-04-07 | Mark Gibson |
| 49 | 1.3.15 | Development |  | 10d | 2006-03-13 | 2006-03-24 |  | 336d | start no earlier than 2006-03-13 | Mark Gibson |
| 50 | 1.3.16 | Deployment r0.4 | milestone | 1d | 2006-05-12 | 2006-05-12 |  | 301d | start no earlier than 2006-05-12 | Mark Gibson |
| 51 | 1.3.17 | Development |  | 40d | 2006-05-14 | 2006-07-06 |  | 261d | start no earlier than 2006-05-13 | Mark Gibson |
| 52 | 1.3.18 | Deployment r0.5 | milestone | 1d | 2006-07-10 | 2006-07-10 |  | 259d | start no earlier than 2006-07-10 | Mark Gibson |
| 53 | 1.3.19 | Pheno-XML validator |  | 1mon | 2005-10-03 | 2005-10-28 |  | 22.25mon | start no earlier than 2005-10-03 | Mark Gibson |
| 54 | 1.3.20 | Phenote production development |  | 85d | 2005-10-03 | 2006-01-24 |  | 380d | start no earlier than 2005-10-03 | Mark Gibson |
| 55 | 1.3.21 | Identification of first 200 genes to annotate phenotypically |  | 3.25mon | 2005-10-03 | 2005-12-28 |  | 7mon | start no earlier than 2005-10-03 | Michael; Monte; Suzanna Lewis |
| 56 | 1.3.22 | Capture 3-way ortholog information |  | 1mon | 2005-10-03 | 2005-10-28 |  | 22.25mon | start no earlier than 2005-10-03 | Chris Mungall |
| 57 | 1.3.23 | Annotation of first 200 fly genes |  | 260d | 2006-07-10 | 2007-07-06 | 55, 27 | 0d | start no earlier than 2006-07-10 | Michael; Monte |
| 58 | 1.3.24 | Annotation of first 200 fish genes |  | 260d | 2006-07-10 | 2007-07-06 | 55, 27 | 0d | start no earlier than 2006-07-10 | Michael; Monte |
| 59 | 1.3.25 | Annotation of first 200 OMIM genes |  | 260d | 2006-07-10 | 2007-07-06 | 55, 27 | 0d | start no earlier than 2006-07-10 | Michael; Monte |

| ID | WBS | Task | Type | Duration | Start | Finish | Total slack | Constraint | Resources |
| --- | --- | --- | --- | --- | --- | --- | --- | --- | --- |
| 60 | 1.4 | **Clinical trial data** |  | 130d | 2006-02-27 | 2006-08-24 | 226d |  |  |
| 61 | 1.4.1 | Loading TrialBank data into OBD |  | 1d | 2006-02-27 | 2006-02-27 | 355d | start no earlier than 2006-02-27 | Chris Mungall |
| 62 | 1.4.2 | Loading TrialBank data into OBD |  | 2d | 2006-06-19 | 2006-06-20 | 273d | start no earlier than 2006-06-19 | Chris Mungall |
| 63 | 1.4.3 | Loading TrialBank data into OBD |  | 2d | 2006-08-21 | 2006-08-22 | 228d | start no earlier than 2006-08-19 | Chris Mungall |
| 64 | 1.4.4 | **Incorporate UMLS into OBD** |  | 59d | 2006-06-05 | 2006-08-24 | 226d |  |  |
| 65 | 1.4.4.1 | Determine portions of UMLS with UCSF |  | 3d | 2006-06-05 | 2006-06-07 | 282d | start no earlier than 2006-06-03 |  |
| 66 | 1.4.4.2 | Download UMLS |  | 5d | 2006-06-12 | 2006-06-16 | 275d | start no earlier than 2006-06-12 |  |
| 67 | 1.4.4.3 | Periodic update of UMLS from OBO |  | 3d | 2006-08-22 | 2006-08-24 | 226d | start no earlier than 2006-08-22 |  |
| 68 | 1.5 | **OBD** |  | 352d | 2005-10-03 | 2007-01-30 | 113d |  |  |
| 69 | 1.5.1 | Evaluate database systems & technologies |  | 2w | 2005-10-03 | 2005-10-14 | 91w | start no earlier than 2005-10-03 | Chris Mungall; ShengQiang Shu |
| 70 | 1.5.2 | Evaluate database systems & technologies |  | 2w | 2006-01-03 | 2006-01-13 | 77.4w | start no earlier than 2006-01-03 | Chris Mungall; ShengQiang Shu |
| 71 | 1.5.3 | OBD Schema design |  | 2w | 2006-01-06 | 2006-01-18 | 76.8w | start no earlier than 2006-01-06 | Chris Mungall; ShengQiang Shu |
| 72 | 1.5.4 | User requirements for OBD queries |  | 3w | 2006-03-21 | 2006-04-10 | 65w | start no earlier than 2006-03-21 | Sima Misra |
| 73 | 1.5.5 | Evaluate database systems & technologies |  | 2w | 2006-04-17 | 2006-04-28 | 62.2w | start no earlier than 2006-04-17 | Chris Mungall; ShengQiang Shu |
| 74 | 1.5.6 | OBD Schema design |  | 2w | 2006-04-17 | 2006-04-28 | 62.2w | start no earlier than 2006-04-17 | Chris Mungall; ShengQiang Shu |
| 75 | 1.5.7 | Design of OBD query interface prototype |  | 3w | 2006-04-17 | 2006-05-05 | 61.2w | start no earlier than 2006-04-17 | Chris Mungall; ShengQiang Shu |
| 76 | 1.5.8 | Development of OBD query interface prototype |  | 3w | 2006-05-17 | 2006-06-06 | 56.6w | start no earlier than 2006-05-17 | Chris Mungall; Nomi Harris; ShengQiang Shu |
| 77 | 1.5.9 | Testing of OBD query interface prototype |  | 3w | 2006-06-19 | 2006-07-07 | 52w | start no earlier than 2006-06-17 | Chris Mungall; Nomi Harris; ShengQiang Shu; Sima Misra |
| 78 | 1.5.10 | Deployment of prototype | milestone | 1d | 2006-07-17 | 2006-07-17 | 254d | start no earlier than 2006-07-17 | Chris Mungall; Nomi Harris; ShengQiang Shu |
| 79 | 1.5.11 | OBD Schema design |  | 2w | 2006-07-17 | 2006-07-28 | 49w | start no earlier than 2006-07-17 | Chris Mungall; ShengQiang Shu |
| 80 | 1.5.12 | **OBD Query system implementation** |  | 120d | 2006-04-17 | 2006-09-28 | 201d |  |  |
| 81 | 1.5.12.1 | OBD Query use cases |  | 2d | 2006-04-17 | 2006-04-18 | 319d | start no earlier than 2006-04-17 | Sima Misra |
| 82 | 1.5.12.2 | OBD Query optimization |  | 4w | 2006-04-18 | 2006-05-14 | 60w | start no earlier than 2006-04-18 | Chris Mungall; Nomi Harris; ShengQiang Shu |
| 83 | 1.5.12.3 | **OBD API** |  | 64d | 2006-07-03 | 2006-09-28 | 201d |  |  |
| 84 | 1.5.12.3.1 | Java API |  | 4w | 2006-07-03 | 2006-07-28 | 49w | start no earlier than 2006-07-01 | Chris Mungall; Nomi Harris; ShengQiang Shu |
| 85 | 1.5.12.3.2 | XML API |  | 4w | 2006-08-03 | 2006-08-30 | 44.4w | start no earlier than 2006-08-03 | Chris Mungall; Nomi Harris; ShengQiang Shu |
| 86 | 1.5.12.3.3 | Web services |  | 4w | 2006-09-01 | 2006-09-28 | 40.2w | start no earlier than 2006-09-01 | Chris Mungall; Nomi Harris; ShengQiang Shu |

| ID | WBS | Task | Type | Duration | Start | Finish | Total slack | Constraint | Resources |
| --- | --- | --- | --- | --- | --- | --- | --- | --- | --- |
| 87 | 1.5.13 | **OBD Foundry data and view layers** |  | 63d | 2006-10-02 | 2006-12-27 | 137d |  |  |
| 88 | 1.5.13.1 | Clinical trial data |  | 1mon | 2006-10-02 | 2006-10-27 | 9mon | start no earlier than 2006-10-01 | Chris Mungall; Nomi Harris; ShengQiang Shu |
| 89 | 1.5.13.2 | Phenote data |  | 2mon | 2006-11-02 | 2006-12-27 | 6.85mon | start no earlier than 2006-11-02 | Chris Mungall; Nomi Harris; ShengQiang Shu |
| 90 | 1.5.14 | **Data submission system** |  | 62d | 2006-06-01 | 2006-08-25 | 225d |  |  |
| 91 | 1.5.14.1 | Evaluate options for different DBPs |  | 2mon | 2006-06-01 | 2006-07-26 | 12.35mon | start no earlier than 2006-06-01 | Chris Mungall; Nomi Harris; ShengQiang Shu |
| 92 | 1.5.14.2 | Generic submission system |  | 2mon | 2006-07-03 | 2006-08-25 | 11.25mon | start no earlier than 2006-07-01 | Chris Mungall; Nomi Harris; ShengQiang Shu |
| 93 | 1.5.15 | Design OBD-BioPortal architecture |  | 2mon | 2006-08-03 | 2006-09-27 | 10.1mon | start no earlier than 2006-08-03 | Chris Mungall; Nomi Harris; ShengQiang Shu |
| 94 | 1.5.16 | **OBO synchronization data flow** |  | 40d | 2006-09-04 | 2006-10-27 | 180d |  |  |
| 95 | 1.5.16.1 | Reconciling OBO changes with annotations |  | 2mon | 2006-09-04 | 2006-10-27 | 9mon | start no earlier than 2006-09-03 | Chris Mungall; Nomi Harris; ShengQiang Shu |
| 96 | 1.5.17 | **BioPortal components** |  | 63d | 2006-11-03 | 2007-01-30 | 113d |  |  |
| 97 | 1.5.17.1 | OBD bioportal prototype | milestone | 2mon | 2006-11-03 | 2006-12-28 | 6.8mon | start no earlier than 2006-11-03 | Chris Mungall; Nomi Harris; ShengQiang Shu |
| 98 | 1.5.17.2 | Visualization of clinical trial data |  | 1mon | 2007-01-03 | 2007-01-30 | 5.65mon | start no earlier than 2007-01-03 | Chris Mungall; Nomi Harris; ShengQiang Shu |
